# Scrum Project Plan_SP

Schedule from MS Project, 2005-11-28 to 2006-05-19, A marks actual dates.
RIT

## Calendars

- Standard: Mon-Fri 08:00-12:00, 13:00-17:30; Sat-Sun off. Exceptions (off unless hours are given): 2006-04-29 to 2006-04-30 08:00-12:00, 13:00-17:00.

## Resources

| Resource |
| --- |
| Scrum Master |
| Product Owner |
| Project Team |
| Quality Assurance |
| Development |
| pro |

## Schedule

| ID | WBS | Task | Duration | Start | Finish | Predecessors | Complete | Constraint | Resources | Work | Actual work |
| --- | --- | --- | --- | --- | --- | --- | --- | --- | --- | --- | --- |
| 1 | 1 | **Peer Eveluation System** | 134.75d | 2005-11-28 A | 2006-05-19 A |  | 100% |  |  | 1279h | 1279h |
| 2 | 1.1 | **Requirements Elicitation** | 47.75d | 2005-11-28 A | 2006-01-27 A |  | 100% |  |  | 371.5h | 371.5h |
| 3 | 1.1.1 | Highlevel Requirements Elicitation and Analysis | 42.44d | 2005-11-28 A | 2006-01-20 A |  | 100% | start no earlier than 2005-11-28 | Project Team | 339.5h | 339.5h |
| 4 | 1.1.2 | Highlevel Requirements Prioritization | 2d | 2006-01-26 A | 2006-01-27 A | 3 | 100% | finish no earlier than 2006-01-27 | Scrum Master; Product Owner | 32h | 32h |
| 5 | 1.2 | **Analysis and Design** | 12.75d | 2006-01-27 A | 2006-02-14 A | 2 | 100% |  |  | 96h | 96h |
| 6 | 1.2.1 | High Level Architecture | 10d | 2006-01-27 A | 2006-02-10 A | 2 | 100% |  | Project Team | 80h | 80h |
| 7 | 1.2.2 | **Database Design** | 2d | 2006-02-13 A | 2006-02-14 A | 6 | 100% |  |  | 16h | 16h |
| 8 | 1.2.2.1 | ER Modeling | 2d | 2006-02-13 A | 2006-02-14 A | 6 | 100% | finish no earlier than 2006-02-14 | Project Team | 16h | 16h |
| 9 | 1.3 | **Initial Setup** | 2d | 2006-01-27 A | 2006-01-31 A | 2 | 100% |  | Project Team | 16h | 16h |
| 10 | 1.3.1 | Database Setup | 2d | 2006-01-27 A | 2006-01-31 A |  | 100% |  |  |  |  |
| 11 | 1.3.2 | Server Setup (IIS) | 1d | 2006-01-27 A | 2006-01-30 A |  | 100% |  |  |  |  |
| 12 | 1.3.3 | Programming Environment | 1d | 2006-01-27 A | 2006-01-30 A |  | 100% |  |  |  |  |
| 13 | 1.4 | Interim Senior Project Presentation | 2d | 2006-02-14 A | 2006-02-16 A | 5 | 100% |  | Scrum Master | 16h | 16h |
| 14 | 1.5 | **Sprint 1** | 40d | 2006-02-18 A | 2006-04-12 A | 13 | 100% |  |  | 256h | 256h |
| 15 | 1.5.1 | **Sprint Planning** | 4d | 2006-02-18 A | 2006-02-23 A |  | 100% |  |  | 64h | 64h |
| 16 | 1.5.1.1 | Feature Negotiation | 4d | 2006-02-18 A | 2006-02-23 A |  | 100% |  | Scrum Master; Product Owner | 64h | 64h |
| 17 | 1.5.2 | **Implementation** | 29d | 2006-02-23 A | 2006-04-04 A | 15 | 100% |  |  | 120h | 120h |
| 18 | 1.5.2.1 | Dataaccess Layer | 4d | 2006-02-23 A | 2006-03-01 A | 15 | 100% |  | Project Team | 32h | 32h |
| 19 | 1.5.2.2 | Create/ Edit/ Delete Evaluations | 11d | 2006-03-01 A | 2006-03-15 A | 18 | 100% |  | Development | 88h | 88h |
| 20 | 1.5.2.3 | Create/ Delete/ Edit Templates | 10d | 2006-03-01 A | 2006-03-14 A | 18 | 100% |  |  |  |  |
| 21 | 1.5.2.4 | LDAP | 14d | 2006-03-15 A | 2006-04-04 A | 19 | 100% |  |  |  |  |
| 22 | 1.5.3 | **Testing** | 6d | 2006-04-04 A | 2006-04-11 A | 17 | 100% |  |  | 64h | 64h |
| 23 | 1.5.3.1 | Unit Testing | 6d | 2006-04-04 A | 2006-04-11 A | 17 | 100% |  | Quality Assurance | 48h | 48h |
| 24 | 1.5.3.2 | Acceptance Testing | 1d | 2006-04-04 A | 2006-04-04 A | 17 | 100% |  | Quality Assurance | 8h | 8h |
| 25 | 1.5.3.3 | Usability Testing | 1d | 2006-04-04 A | 2006-04-04 A | 17 | 100% |  | Quality Assurance | 8h | 8h |
| 26 | 1.5.4 | Delivery | 1d | 2006-04-11 A | 2006-04-12 A | 22 | 100% |  | Project Team | 8h | 8h |

| ID | WBS | Task | Type | Duration | Start | Finish | Predecessors | Complete | Constraint | Resources | Work | Actual work |
| --- | --- | --- | --- | --- | --- | --- | --- | --- | --- | --- | --- | --- |
| 27 | 1.6 | **Sprint 2** |  | 14.12d | 2006-04-12 A | 2006-04-29 A | 14 | 100% |  |  | 224h | 224h |
| 28 | 1.6.1 | **Sprint Planning** |  | 3d | 2006-04-12 A | 2006-04-17 A |  | 100% |  |  | 80h | 80h |
| 29 | 1.6.1.1 | Priority and new requirement analysis |  | 2d | 2006-04-12 A | 2006-04-14 A |  | 100% |  | Scrum Master; Product Owner; Project Team | 48h | 48h |
| 30 | 1.6.1.2 | Usability feedback analysis |  | 1d | 2006-04-12 A | 2006-04-13 A |  | 100% |  | Scrum Master; Project Team | 16h | 16h |
| 31 | 1.6.1.3 | Feature Negotiation |  | 1d | 2006-04-14 A | 2006-04-17 A | 29, 30 | 100% |  | Scrum Master; Product Owner | 16h | 16h |
| 32 | 1.6.2 | **Implementation** |  | 7d | 2006-04-17 A | 2006-04-26 A | 28 | 100% |  |  | 48h | 48h |
| 33 | 1.6.2.1 | Student Main (Take Evaluations) |  | 7d | 2006-04-17 A | 2006-04-26 A |  | 100% |  |  |  |  |
| 34 | 1.6.2.2 | Reporting Summary (View-1, View-2) |  | 6d | 2006-04-17 A | 2006-04-25 A |  | 100% |  |  |  |  |
| 35 | 1.6.2.3 | LDAP |  | 6d | 2006-04-17 A | 2006-04-25 A | 28 | 100% |  | Development | 48h | 48h |
| 36 | 1.6.3 | **Testing** |  | 9.44d | 2006-04-18 A | 2006-04-28 A |  | 100% |  |  | 88h | 88h |
| 37 | 1.6.3.1 | Unit Testing |  | 6d | 2006-04-18 A | 2006-04-25 A |  | 100% | start no earlier than 2006-04-18 | Quality Assurance | 48h | 48h |
| 38 | 1.6.3.2 | Acceptance Testing |  | 1d | 2006-04-26 A | 2006-04-26 A | 32 | 100% |  | Quality Assurance | 8h | 8h |
| 39 | 1.6.3.3 | Usability Testing |  | 1d | 2006-04-26 A | 2006-04-26 A | 32 | 100% |  | Quality Assurance | 8h | 8h |
| 40 | 1.6.3.4 | Integration Testing |  | 3d | 2006-04-26 A | 2006-04-28 A | 32 | 100% |  | Quality Assurance | 24h | 24h |
| 41 | 1.6.4 | Delivery |  | 1d | 2006-04-29 A | 2006-04-29 A | 40 | 100% | finish no earlier than 2006-04-29 | Project Team | 8h | 8h |
| 42 | 1.7 | **Sprint 3** |  | 11.56d | 2006-04-30 A | 2006-05-12 A | 27 | 100% |  |  | 228.5h | 228.5h |
| 43 | 1.7.1 | **Sprint Planning** |  | 1d | 2006-04-30 A | 2006-04-30 A |  | 100% |  |  | 40h | 40h |
| 44 | 1.7.1.1 | Priority and new requirement analysis |  | 1d | 2006-04-30 A | 2006-04-30 A |  | 100% |  | Scrum Master; Product Owner; Project Team | 24h | 24h |
| 45 | 1.7.1.2 | Usability feedback analysis |  | 1d | 2006-04-30 A | 2006-04-30 A |  | 100% |  | Scrum Master; Project Team | 16h | 16h |
| 46 | 1.7.1.3 | Feature Negotiation | milestone | 0d | 2006-04-30 A | 2006-04-30 A | 44, 45 | 100% |  | Scrum Master; Product Owner |  |  |
| 47 | 1.7.2 | **Implementation** |  | 6d | 2006-05-01 A | 2006-05-08 A | 43 | 100% |  |  | 48h | 48h |
| 48 | 1.7.2.1 | UI changes |  | 3d | 2006-05-01 A | 2006-05-03 A |  | 100% |  |  |  |  |
| 49 | 1.7.2.2 | Reporting Summary (View-1, View-2) In Detail |  | 6d | 2006-05-01 A | 2006-05-08 A |  | 100% |  | Development | 48h | 48h |
| 50 | 1.7.2.3 | Instructor Main (Cosmetic Changes) |  | 3d | 2006-05-01 A | 2006-05-03 A |  | 100% |  |  |  |  |
| 51 | 1.7.2.4 | Partial Summary |  | 3d | 2006-05-01 A | 2006-05-03 A |  | 100% |  |  |  |  |
| 52 | 1.7.2.5 | myCourses Integration |  | 5d | 2006-05-01 A | 2006-05-05 A |  | 100% |  |  |  |  |
| 53 | 1.7.2.6 | Submittions Status |  | 2d | 2006-05-01 A | 2006-05-02 A |  | 100% |  |  |  |  |

| ID | WBS | Task | Duration | Start | Finish | Predecessors | Complete | Constraint | Resources | Work | Actual work |
| --- | --- | --- | --- | --- | --- | --- | --- | --- | --- | --- | --- |
| 54 | 1.7.3 | **Testing** | 10.56d | 2006-05-01 A | 2006-05-12 A |  | 100% |  |  | 140.5h | 140.5h |
| 55 | 1.7.3.1 | Unit Testing | 5d | 2006-05-01 A | 2006-05-05 A | 43 | 100% |  | Quality Assurance | 40h | 40h |
| 56 | 1.7.3.2 | Acceptance Testing | 1d | 2006-05-08 A | 2006-05-09 A | 47 | 100% |  | Quality Assurance | 8h | 8h |
| 57 | 1.7.3.3 | Usability Testing | 1d | 2006-05-08 A | 2006-05-09 A | 47 | 100% |  | Quality Assurance | 8h | 8h |
| 58 | 1.7.3.4 | Integration Testing | 10.56d | 2006-05-01 A | 2006-05-12 A | 43 | 100% |  | Quality Assurance | 84.5h | 84.5h |
| 59 | 1.8 | **Final Delivery** | 8.88d | 2006-05-09 A | 2006-05-19 A | 54 | 100% |  | Project Team | 71h | 71h |
| 60 | 1.8.1 | Presentation | 3.56d | 2006-05-09 A | 2006-05-17 A |  | 100% | finish no earlier than 2006-05-12 |  |  |  |
| 61 | 1.8.2 | Release Documents | 3.12d | 2006-05-17 A | 2006-05-19 A |  | 100% | finish no earlier than 2006-05-19 |  |  |  |
| 62 | 1.8.3 | Minor UI Changes- As Per Client | 1d | 2006-05-17 A | 2006-05-17 A |  | 100% | start no earlier than 2006-05-17 |  |  |  |
